# SUBPROYECTO A3

Schedule from Primavera P6, 2023-04-25 to 2023-11-04, data date 2023-04-25.

## Calendars

- 2T - 6x1 - 8 hr: Mon-Sat 02:00-06:00, 08:00-12:00, 14:00-18:00, 20:00-00:00; Sun off. Exceptions (off unless hours are given): 2023-05-01, 2023-06-29, 2023-07-28 to 2023-07-29, 2023-08-30, 2023-11-01.

## Schedule

| ID | WBS | Activity | Type | Duration | Start | Finish | Predecessors | Total float | Free float |
| --- | --- | --- | --- | --- | --- | --- | --- | --- | --- |
|  | 0 | **HITOS** |  |  | 2023-04-25 | 2023-11-03 |  |  |  |
| A1000 |  | ADJUDICACION DEL SERVICIO | milestone | 0d | 2023-04-25 | 2023-04-25 |  | 0d |  |
| A1010 |  | INICIO DEL SERVICIO | milestone | 0d | 2023-05-09 | 2023-05-09 | A1000 FS+11d | 0d |  |
| A1015 |  | INICIO DE EXCAVACION | milestone | 0d | 2023-05-15 | 2023-05-15 | A1010 FS+5d, A1070 SS+3d | 0d |  |
| A1016 |  | INICIO DE RELLENO DE DIQUE | milestone | 0d | 2023-06-06 | 2023-06-06 | A1015 SS+18d, A1340 | 0d |  |
| A1020 |  | FIN DEL SERVICIO | milestone | 0d | 2023-11-03 | 2023-11-03 | A1200, A2220, A2490, A1760, A1780, A1070, A2760, A2700, A1050, A2210, A4020, A3850, A3790, A3780, A3740, A3730, A3670, A3650, A3640, A3630, A3580, A3560, A3550, A3530, A3470, A3450, A3400, A3260, A3160, A3140, A3130, A3080, A2930, A2880 | 0d |  |
|  | 1 | **DEFENSAS RIBEREÑAS** |  |  | 2023-05-09 | 2023-11-04 |  |  |  |
|  | 1 | **OBRAS PRELIMINARES** |  |  | 2023-05-11 | 2023-10-31 |  |  |  |
| A1030 |  | CARTEL DE IDENTIFICACIÓN OBRA 4.80 x 3.60 m. |  | 2d | 2023-05-11 | 2023-05-13 | A1060 SS+2.5d | 1.75d |  |
| A1040 |  | INSTALACIONES PROVISIONALES PARA LA OBRA |  | 140d | 2023-05-16 | 2023-10-31 | A1100 SS+1.25d, A1030 | 0d |  |
| A1050 |  | MANTENIMIENTO DE TRÁNSITO Y SEGURIDAD VIAL |  | 127d | 2023-05-31 | 2023-10-31 | A1100 | 2.25d |  |
|  | 2 | **TRABAJOS PRELIMINARES** |  |  | 2023-05-09 | 2023-11-04 |  |  |  |
| A1060 |  | MOVILIZACION DE EQUIPOS |  | 26d | 2023-05-09 | 2023-06-08 | A1010 | 0d |  |
| A1070 |  | TOPOGRAFÍA Y GEOREFERENCIACIÓN |  | 144d | 2023-05-11 | 2023-10-31 | A1060 SS+2d | 0d |  |
| A1080 |  | DESMOVILIZACION DE EQUIPOS |  | 18d | 2023-10-13 | 2023-11-04 | A1020 FF+1d | 0d |  |
|  | 3 | **MEJORAMIENTO DE VÍAS EXISTENTES** |  |  | 2023-05-15 | 2023-07-13 |  |  |  |
|  | 1 | **MOVIMIENTO DE TIERRAS** |  |  | 2023-05-15 | 2023-05-31 |  |  |  |
| A1090 |  | ROCE Y LIMPIEZA DE MALEZA |  | 14d | 2023-05-15 | 2023-05-31 | A1015 | 0d |  |
| A1100 |  | MEJORAMIENTO DE VIAS EXISTENTES |  | 14d | 2023-05-15 | 2023-05-31 | A1090 SS | 0d |  |
|  | 2 | **REPOSICIÓN DE ESTRUCTURAS** |  |  | 2023-06-03 | 2023-07-07 |  |  |  |
| A1150 |  | DEMOLICIÓN DE ESTRUCTURAS EXISTENTES |  | 2d | 2023-06-03 | 2023-06-06 | A1070 SS+20d | 93.25d | 0d |
| A1160 |  | REPOSICIÓN DE PASE DE AGUA TUBO HDPE Ø=18" |  | 2d | 2023-06-06 | 2023-06-08 | A1150 | 93.25d | 0d |
| A1170 |  | REPOSICIÓN DE PASE DE AGUA TUBO HDPE Ø=36" |  | 2d | 2023-06-06 | 2023-06-08 | A1160 SS | 93.25d | 0d |
| A1180 |  | SUMINISTRO Y MONTAJE DE PANELES DE C°A° 1.6mx1.0mx0.20m EN PASE DE AGUA |  | 24d | 2023-06-08 | 2023-07-07 | A1170 | 93.25d | 0d |
| A1190 |  | SUMINISTRO Y MONTAJE DE PANELES DE C°A° 2.20mx1.0mx0.20m EN PASE DE AGUA |  | 24d | 2023-06-08 | 2023-07-07 | A1180 SS | 93.25d | 0d |

| ID | WBS | Activity | Duration | Start | Finish | Predecessors | Total float | Free float | Filtro |
| --- | --- | --- | --- | --- | --- | --- | --- | --- | --- |
|  | 4 | **CABEZAL DE ENTRADA Y SALIDA** |  | 2023-07-07 | 2023-07-13 |  |  |  |  |
| A1210 |  | ENCOFRADO Y DESENCOFRADO RECTO | 3d | 2023-07-07 | 2023-07-11 | A1190 | 93.25d | 0d |  |
| A1200 |  | CONCRETOS | 2d | 2023-07-11 | 2023-07-13 | A1210 | 93.25d |  |  |
|  | 4 | **DESCOLMATACIÓN DE CAUCE Y OBRAS AUXILIARES** |  | 2023-05-17 | 2023-11-03 |  |  |  |  |
|  | 1 | **DESBROCE Y DESCOLMATACIÓN** |  | 2023-05-17 | 2023-08-11 |  |  |  |  |
| A1220 |  | DESBROCE Y LIMPIEZA EN ZONA NO BOSCOSA | 61d | 2023-05-17 | 2023-07-31 | A1070 SS+4d, A1015, A1040 SS+1.25d | 0d |  | Excavación |
| A1230 |  | DESCOLMATACIÓN DE CAUCE NATURAL DEL RÍO LACRAMARCA - DIQUE A3-D-01 | 8d | 2023-05-17 | 2023-05-26 | A1220 SS | 0d |  | Excavación |
| A1880 |  | DESCOLMATACIÓN DE CAUCE NATURAL DEL RÍO LACRAMARCA - DIQUE A3-I-01 | 27d | 2023-05-17 | 2023-06-17 | A1230 SS | 0d |  | Excavación |
| A1870 |  | DESCOLMATACIÓN DE CAUCE NATURAL DEL RÍO LACRAMARCA - DIQUE A3-D-02 | 43d | 2023-05-26 | 2023-07-17 | A1230 | 33d |  | Excavación |
| A1890 |  | DESCOLMATACIÓN DE CAUCE NATURAL DEL RÍO LACRAMARCA - DIQUE A3-I-02 | 16d | 2023-06-17 | 2023-07-07 | A1880 | 12.75d | 0d | Excavación |
| A1900 |  | DESCOLMATACIÓN DE CAUCE NATURAL DEL RÍO LACRAMARCA - DIQUE A3-I-03 | 28d | 2023-07-07 | 2023-08-11 | A1890 | 14.75d | 2d | Excavación |
|  | 2 | **DESVIO DEL CAUCE** |  | 2023-05-18 | 2023-11-03 |  |  |  |  |
|  | 1 | **A3-D-01** |  | 2023-06-17 | 2023-06-28 |  |  |  |  |
| A1240 |  | CONFORMACIÓN DE DESVIO EN CAUCE DE RÍO - DIQUE A3-D-01 | 4d | 2023-06-17 | 2023-06-22 | A1230 SS+2d, A1330 FF+1d | 0d |  | Excavación |
| A1250 |  | RELLENO NO ESTRUCTURAL CON MATERIAL PROPIO - DIQUE A3-D-01 | 6d | 2023-06-21 | 2023-06-28 | A1330 | 74.75d | 14d | Relleno |
|  | 2 | **A3-D-02** |  | 2023-07-07 | 2023-10-18 |  |  |  |  |
| A1790 |  | CONFORMACIÓN DE DESVIO EN CAUCE DE RÍO - DIQUE A3-D-02 - TRAMO 1 | 4d | 2023-07-07 | 2023-07-12 | A1870 SS+2d, A1510 FF+1d | 0d |  | Excavación |
| A1800 |  | RELLENO NO ESTRUCTURAL CON MATERIAL PROPIO - DIQUE A3-D-02 - TRAMO 1 | 6d | 2023-07-15 | 2023-07-22 | A1420, A1250 | 60.75d | 12d | Relleno |
| A2630 |  | CONFORMACIÓN DE DESVIO EN CAUCE DE RÍO - DIQUE A3-D-02 - TRAMO 2 | 4d | 2023-07-31 | 2023-08-04 | A1600 FF+1d | 0d |  | Excavación |
| A2640 |  | RELLENO NO ESTRUCTURAL CON MATERIAL PROPIO - DIQUE A3-D-02 - TRAMO 2 | 6d | 2023-08-08 | 2023-08-15 | A1980, A1800 | 48.75d | 12d | Relleno |
| A2650 |  | CONFORMACIÓN DE DESVIO EN CAUCE DE RÍO - DIQUE A3-D-02 - TRAMO 3 | 4d | 2023-08-21 | 2023-08-25 | A1690 FF+1d | 0d |  | Excavación |
| A2660 |  | RELLENO NO ESTRUCTURAL CON MATERIAL PROPIO - DIQUE A3-D-02 - TRAMO 3 | 6d | 2023-08-29 | 2023-09-06 | A2070, A2640 | 36.75d | 12d | Relleno |
| A2670 |  | CONFORMACIÓN DE DESVIO EN CAUCE DE RÍO - DIQUE A3-D-02 - TRAMO 4 | 4d | 2023-09-12 | 2023-09-16 | A2340 FF+1d | 0d |  | Excavación |
| A2680 |  | RELLENO NO ESTRUCTURAL CON MATERIAL PROPIO - DIQUE A3-D-02 - TRAMO 4 | 6d | 2023-09-20 | 2023-09-27 | A2160, A2660 | 24.75d | 12d | Relleno |
| A2690 |  | CONFORMACIÓN DE DESVIO EN CAUCE DE RÍO - DIQUE A3-D-02 - TRAMO 5 | 4d | 2023-10-03 | 2023-10-07 | A2430 FF+1d | 0d |  | Excavación |
| A2700 |  | RELLENO NO ESTRUCTURAL CON MATERIAL PROPIO - DIQUE A3-D-02 - TRAMO 5 | 6d | 2023-10-11 | 2023-10-18 | A2250, A2680 | 12.75d |  | Relleno |

| ID | WBS | Activity | Duration | Start | Finish | Predecessors | Total float | Free float | Filtro |
| --- | --- | --- | --- | --- | --- | --- | --- | --- | --- |
|  | 3 | **A3-I-01** |  | 2023-05-18 | 2023-07-18 |  |  |  |  |
| A1810 |  | CONFORMACIÓN DE DESVIO EN CAUCE DE RÍO - DIQUE A3-I-01 | 4d | 2023-05-18 | 2023-05-23 | A1880 SS+1d | 0d |  | Excavación |
| A1820 |  | RELLENO NO ESTRUCTURAL CON MATERIAL PROPIO - DIQUE A3-I-01 | 6d | 2023-07-11 | 2023-07-18 | A1510 | 59.75d | 11.75d | Relleno |
|  | 4 | **A3-I-02** |  | 2023-06-20 | 2023-08-10 |  |  |  |  |
| A1830 |  | CONFORMACIÓN DE DESVIO EN CAUCE DE RÍO - DIQUE A3-I-02 | 4d | 2023-06-20 | 2023-06-24 | A1890 SS+2d, A1330 FF+1d | 12.75d | 0d | Excavación |
| A1840 |  | RELLENO NO ESTRUCTURAL CON MATERIAL PROPIO - DIQUE A3-I-02 | 6d | 2023-08-03 | 2023-08-10 | A1600, A1820 | 48d | 12d | Relleno |
|  | 5 | **A3-I-03** |  | 2023-07-12 | 2023-11-03 |  |  |  |  |
| A1850 |  | CONFORMACIÓN DE DESVIO EN CAUCE DE RÍO - DIQUE A3-I-03 - TRAMO 1 | 4d | 2023-07-12 | 2023-07-17 | A1900 SS+2d, A1420 FF+1d | 12.75d | 0d | Excavación |
| A2710 |  | CONFORMACIÓN DE DESVIO EN CAUCE DE RÍO - DIQUE A3-I-03 - TRAMO 2 | 4d | 2023-08-04 | 2023-08-09 | A1980 FF+1d | 12.75d | 0d | Excavación |
| A1860 |  | RELLENO NO ESTRUCTURAL CON MATERIAL PROPIO - DIQUE A3-I-03 -TRAMO 1 | 6d | 2023-08-24 | 2023-09-01 | A1690, A1840 | 36d | 12d | Relleno |
| A2730 |  | CONFORMACIÓN DE DESVIO EN CAUCE DE RÍO - DIQUE A3-I-03 - TRAMO 3 | 4d | 2023-08-25 | 2023-08-31 | A2070 FF+1d | 12.75d | 0d | Excavación |
| A2720 |  | RELLENO NO ESTRUCTURAL CON MATERIAL PROPIO - DIQUE A3-I-03 -TRAMO 2 | 6d | 2023-09-15 | 2023-09-22 | A2340, A1860 | 24d | 12d | Relleno |
| A2750 |  | CONFORMACIÓN DE DESVIO EN CAUCE DE RÍO - DIQUE A3-I-03 - TRAMO 4 | 4d | 2023-09-16 | 2023-09-21 | A2160 FF+1d | 12.75d | 0d | Excavación |
| A2740 |  | RELLENO NO ESTRUCTURAL CON MATERIAL PROPIO - DIQUE A3-I-03 -TRAMO3 | 6d | 2023-10-06 | 2023-10-13 | A2430, A2720 | 12d |  | Relleno |
| A2760 |  | RELLENO NO ESTRUCTURAL CON MATERIAL PROPIO - DIQUE A3-I-03 -TRAMO 4 | 5d | 2023-10-27 | 2023-11-03 | A2520, A2740 | 0d |  | Relleno |
|  | 5 | **DIQUES DE TIERRA COMPACTADA CON ENROCADO** |  | 2023-05-23 | 2023-10-30 |  |  |  |  |
|  | 1 | **DIQUE DE TIERRA COMPACTADA A3-D-01** |  | 2023-05-23 | 2023-06-23 |  |  |  |  |
| A1260 |  | EXCAVACIÓN EN TERRENO NATURAL CON EQUIPO | 8d | 2023-05-23 | 2023-06-01 | A1810 | 0d |  | Excavación |
| A1270 |  | EXCAVACIÓN DE UÑA CON EQUIPO | 7d | 2023-05-24 | 2023-06-01 | A1260 SS+1.25d | 76.5d | 21d | Excavación |
| A1280 |  | PERFILADO Y COMPACTACIÓN EN ZONA DE CORTE | 16d | 2023-05-24 | 2023-06-12 | A1260 SS+1.25d | 0d |  |  |
| A1340 |  | PREPARACIÓN DE FUNDACIÓN DE CUERPO DE DIQUE | 11d | 2023-05-24 | 2023-06-06 | A1280 SS | 0d |  |  |
| A1290 |  | CONFORMACIÓN DE CUERPO DE DIQUE CON MATERIAL PROPIO | 4d | 2023-06-06 | 2023-06-10 | A1016 | 0d |  | Relleno |
| A1310 |  | GEOTEXTIL NO TEJIDO 400 G/M2, INC. COLOCACIÓN | 5d | 2023-06-08 | 2023-06-14 | A1290 SS+1.25d | 0d |  |  |
| A1320 |  | COLOCACION Y ACOMODO DE ROCA EN UÑA DE DIQUE | 5d | 2023-06-09 | 2023-06-15 | A1310 SS+1.25d | 0d |  | Roca |
| A1330 |  | COLOCACION Y ACOMODO DE ROCA EN TALUD DE DIQUE | 9d | 2023-06-10 | 2023-06-21 | A1320 SS+1.25d | 0d |  | Roca |
| A1300 |  | CONFORMACIÓN DE CORONA DE DIQUE CON MATERIAL PROPIO | 5d | 2023-06-17 | 2023-06-23 | A1330 FF+2d | 83.75d | 15d | Relleno |

| ID | WBS | Activity | Duration | Start | Finish | Predecessors | Total float | Free float | Filtro |
| --- | --- | --- | --- | --- | --- | --- | --- | --- | --- |
|  | 2 | **DIQUE DE TIERRA COMPACTADA A3-D-02** |  | 2023-06-24 | 2023-10-13 |  |  |  |  |
|  | 1 | **TRAMO 1** |  | 2023-06-24 | 2023-07-18 |  |  |  |  |
| A1350 |  | EXCAVACIÓN EN TERRENO NATURAL CON EQUIPO | 7d | 2023-06-24 | 2023-07-04 | A1830 | 12.75d | 0d | Excavación |
| A1360 |  | EXCAVACIÓN DE UÑA CON EQUIPO | 9d | 2023-06-26 | 2023-07-07 | A1350 SS+1.25d, A1270 | 55.5d | 9d | Excavación |
| A1370 |  | PERFILADO Y COMPACTACIÓN EN ZONA DE CORTE | 10d | 2023-06-26 | 2023-07-08 | A1350 SS+1.25d | 12.75d | 0d |  |
| A1400 |  | GEOTEXTIL NO TEJIDO 400 G/M2, INC. COLOCACIÓN | 10d | 2023-06-28 | 2023-07-11 | A1370 SS+1.25d | 12.75d | 0d |  |
| A1410 |  | COLOCACION Y ACOMODO DE ROCA EN UÑA DE DIQUE | 13d | 2023-06-30 | 2023-07-15 | A1400 SS+1.25d | 12.75d | 0d | Roca |
| A1420 |  | COLOCACION Y ACOMODO DE ROCA EN TALUD DE DIQUE | 12d | 2023-07-01 | 2023-07-15 | A1410 SS+1.25d | 12.75d | 0d | Roca |
| A1430 |  | PREPARACIÓN DE FUNDACIÓN DE CUERPO DE DIQUE | 4d | 2023-07-04 | 2023-07-08 | A1350 | 79.75d | 0d |  |
| A1380 |  | CONFORMACIÓN DE CUERPO DE DIQUE CON MATERIAL PROPIO | 4d | 2023-07-05 | 2023-07-10 | A1430 SS+1d | 79.75d | 14d | Relleno |
| A1390 |  | CONFORMACIÓN DE CORONA DE DIQUE CON MATERIAL PROPIO | 5d | 2023-07-12 | 2023-07-18 | A1420 FF+2d, A1300 | 68.75d | 13d | Relleno |
|  | 2 | **TRAMO 2** |  | 2023-07-17 | 2023-08-10 |  |  |  |  |
| A1910 |  | EXCAVACIÓN EN TERRENO NATURAL CON EQUIPO | 7d | 2023-07-17 | 2023-07-25 | A1850 | 12.75d | 0d | Excavación |
| A1920 |  | EXCAVACIÓN DE UÑA CON EQUIPO | 9d | 2023-07-18 | 2023-07-31 | A1910 SS+1.25d, A1360 | 46.5d | 9d | Excavación |
| A1930 |  | PERFILADO Y COMPACTACIÓN EN ZONA DE CORTE | 10d | 2023-07-18 | 2023-08-01 | A1910 SS+1.25d | 12.75d | 0d |  |
| A1960 |  | GEOTEXTIL NO TEJIDO 400 G/M2, INC. COLOCACIÓN | 10d | 2023-07-20 | 2023-08-03 | A1930 SS+1.25d | 12.75d | 0d |  |
| A1970 |  | COLOCACION Y ACOMODO DE ROCA EN UÑA DE DIQUE | 13d | 2023-07-21 | 2023-08-08 | A1960 SS+1.25d | 12.75d | 0d | Roca |
| A1980 |  | COLOCACION Y ACOMODO DE ROCA EN TALUD DE DIQUE | 12d | 2023-07-22 | 2023-08-08 | A1970 SS+1.25d | 12.75d | 0d | Roca |
| A1990 |  | PREPARACIÓN DE FUNDACIÓN DE CUERPO DE DIQUE | 4d | 2023-07-25 | 2023-08-01 | A1910 | 65.75d | 0d |  |
| A1940 |  | CONFORMACIÓN DE CUERPO DE DIQUE CON MATERIAL PROPIO | 4d | 2023-07-26 | 2023-08-02 | A1990 SS+1d, A1380 | 65.75d | 14d | Relleno |
| A1950 |  | CONFORMACIÓN DE CORONA DE DIQUE CON MATERIAL PROPIO | 5d | 2023-08-04 | 2023-08-10 | A1980 FF+2d, A1390 | 55.75d | 13d | Relleno |
|  | 3 | **TRAMO 3** |  | 2023-08-09 | 2023-09-01 |  |  |  |  |
| A2000 |  | EXCAVACIÓN EN TERRENO NATURAL CON EQUIPO | 7d | 2023-08-09 | 2023-08-17 | A2710 | 12.75d | 0d | Excavación |
| A2010 |  | EXCAVACIÓN DE UÑA CON EQUIPO | 9d | 2023-08-10 | 2023-08-21 | A2000 SS+1.25d, A1920 | 37.5d | 9d | Excavación |
| A2020 |  | PERFILADO Y COMPACTACIÓN EN ZONA DE CORTE | 10d | 2023-08-10 | 2023-08-22 | A2000 SS+1.25d | 12.75d | 0d |  |
| A2050 |  | GEOTEXTIL NO TEJIDO 400 G/M2, INC. COLOCACIÓN | 10d | 2023-08-12 | 2023-08-24 | A2020 SS+1.25d | 12.75d | 0d |  |
| A2060 |  | COLOCACION Y ACOMODO DE ROCA EN UÑA DE DIQUE | 13d | 2023-08-14 | 2023-08-29 | A2050 SS+1.25d | 12.75d | 0d | Roca |
| A2070 |  | COLOCACION Y ACOMODO DE ROCA EN TALUD DE DIQUE | 12d | 2023-08-15 | 2023-08-29 | A2060 SS+1.25d | 12.75d | 0d | Roca |
| A2080 |  | PREPARACIÓN DE FUNDACIÓN DE CUERPO DE DIQUE | 4d | 2023-08-17 | 2023-08-22 | A2000 | 51.75d | 0d |  |
| A2030 |  | CONFORMACIÓN DE CUERPO DE DIQUE CON MATERIAL PROPIO | 4d | 2023-08-18 | 2023-08-23 | A2080 SS+1d, A1940 | 51.75d | 14d | Relleno |
| A2040 |  | CONFORMACIÓN DE CORONA DE DIQUE CON MATERIAL PROPIO | 5d | 2023-08-25 | 2023-09-01 | A2070 FF+2d, A1950 | 42.75d | 13d | Relleno |

| ID | WBS | Activity | Duration | Start | Finish | Predecessors | Total float | Free float | Filtro |
| --- | --- | --- | --- | --- | --- | --- | --- | --- | --- |
|  | 4 | **TRAMO 4** |  | 2023-08-31 | 2023-09-22 |  |  |  |  |
| A2090 |  | EXCAVACIÓN EN TERRENO NATURAL CON EQUIPO | 7d | 2023-08-31 | 2023-09-08 | A2730 | 12.75d | 0d | Excavación |
| A2100 |  | EXCAVACIÓN DE UÑA CON EQUIPO | 9d | 2023-09-01 | 2023-09-12 | A2090 SS+1.25d, A2010 | 28.5d | 9d | Excavación |
| A2110 |  | PERFILADO Y COMPACTACIÓN EN ZONA DE CORTE | 10d | 2023-09-01 | 2023-09-13 | A2090 SS+1.25d | 12.75d | 0d |  |
| A2140 |  | GEOTEXTIL NO TEJIDO 400 G/M2, INC. COLOCACIÓN | 10d | 2023-09-04 | 2023-09-15 | A2110 SS+1.25d | 12.75d | 0d |  |
| A2150 |  | COLOCACION Y ACOMODO DE ROCA EN UÑA DE DIQUE | 13d | 2023-09-05 | 2023-09-20 | A2140 SS+1.25d | 12.75d | 0d | Roca |
| A2160 |  | COLOCACION Y ACOMODO DE ROCA EN TALUD DE DIQUE | 12d | 2023-09-06 | 2023-09-20 | A2150 SS+1.25d | 12.75d | 0d | Roca |
| A2170 |  | PREPARACIÓN DE FUNDACIÓN DE CUERPO DE DIQUE | 4d | 2023-09-08 | 2023-09-13 | A2090 | 37.75d | 0d |  |
| A2120 |  | CONFORMACIÓN DE CUERPO DE DIQUE CON MATERIAL PROPIO | 4d | 2023-09-09 | 2023-09-14 | A2170 SS+1d, A2030 | 37.75d | 14d | Relleno |
| A2130 |  | CONFORMACIÓN DE CORONA DE DIQUE CON MATERIAL PROPIO | 5d | 2023-09-16 | 2023-09-22 | A2160 FF+2d, A2040 | 29.75d | 13d | Relleno |
|  | 5 | **TRAMO 5** |  | 2023-09-21 | 2023-10-13 |  |  |  |  |
| A2180 |  | EXCAVACIÓN EN TERRENO NATURAL CON EQUIPO | 7d | 2023-09-21 | 2023-09-29 | A2750 | 12.75d | 0d | Excavación |
| A2190 |  | EXCAVACIÓN DE UÑA CON EQUIPO | 9d | 2023-09-22 | 2023-10-03 | A2180 SS+1.25d, A2100 | 19.5d | 0d | Excavación |
| A2200 |  | PERFILADO Y COMPACTACIÓN EN ZONA DE CORTE | 10d | 2023-09-22 | 2023-10-04 | A2180 SS+1.25d | 12.75d | 0d |  |
| A2230 |  | GEOTEXTIL NO TEJIDO 400 G/M2, INC. COLOCACIÓN | 10d | 2023-09-25 | 2023-10-06 | A2200 SS+1.25d | 12.75d | 0d |  |
| A2240 |  | COLOCACION Y ACOMODO DE ROCA EN UÑA DE DIQUE | 13d | 2023-09-26 | 2023-10-11 | A2230 SS+1.25d | 12.75d | 0d | Roca |
| A2250 |  | COLOCACION Y ACOMODO DE ROCA EN TALUD DE DIQUE | 12d | 2023-09-27 | 2023-10-11 | A2240 SS+1.25d | 12.75d | 0d | Roca |
| A2260 |  | PREPARACIÓN DE FUNDACIÓN DE CUERPO DE DIQUE | 4d | 2023-09-29 | 2023-10-04 | A2180 | 23.75d | 0d |  |
| A2210 |  | CONFORMACIÓN DE CUERPO DE DIQUE CON MATERIAL PROPIO | 4d | 2023-09-30 | 2023-10-05 | A2260 SS+1d, A2120 | 23.75d |  | Relleno |
| A2220 |  | CONFORMACIÓN DE CORONA DE DIQUE CON MATERIAL PROPIO | 5d | 2023-10-07 | 2023-10-13 | A2250 FF+2d, A2130 | 16.75d |  | Relleno |
|  | 3 | **DIQUE DE TIERRA COMPACTADA A3-I-01** |  | 2023-06-22 | 2023-07-13 |  |  |  |  |
| A1440 |  | EXCAVACIÓN EN TERRENO NATURAL CON EQUIPO | 9d | 2023-06-22 | 2023-07-04 | A1240 | 0d |  | Excavación |
| A1450 |  | EXCAVACIÓN DE UÑA CON EQUIPO | 8d | 2023-06-23 | 2023-07-04 | A1440 SS+1.25d | 49.5d | 8d | Excavación |
| A1460 |  | PERFILADO Y COMPACTACIÓN EN ZONA DE CORTE | 9d | 2023-06-23 | 2023-07-05 | A1440 SS+1.25d | 0d |  |  |
| A1520 |  | PREPARACIÓN DE FUNDACIÓN DE CUERPO DE DIQUE | 9d | 2023-06-23 | 2023-07-05 | A1460 SS | 0d |  |  |
| A1470 |  | CONFORMACIÓN DE CUERPO DE DIQUE CON MATERIAL PROPIO | 6d | 2023-06-24 | 2023-07-03 | A1520 SS+1d | 0d |  | Relleno |
| A1490 |  | GEOTEXTIL NO TEJIDO 400 G/M2, INC. COLOCACIÓN | 5d | 2023-06-27 | 2023-07-04 | A1470 SS+1.25d | 0d |  |  |
| A1500 |  | COLOCACION Y ACOMODO DE ROCA EN UÑA DE DIQUE | 5d | 2023-06-28 | 2023-07-05 | A1490 SS+1.25d | 0d |  | Roca |
| A1510 |  | COLOCACION Y ACOMODO DE ROCA EN TALUD DE DIQUE | 9d | 2023-06-30 | 2023-07-11 | A1500 SS+1.25d | 0d |  | Roca |
| A1480 |  | CONFORMACIÓN DE CORONA DE DIQUE CON MATERIAL PROPIO | 4d | 2023-07-08 | 2023-07-13 | A1510 FF+2d | 26.25d | 12.75d | Relleno |

| ID | WBS | Activity | Duration | Start | Finish | Predecessors | Total float | Free float | Filtro |
| --- | --- | --- | --- | --- | --- | --- | --- | --- | --- |
|  | 4 | **DIQUE DE TIERRA COMPACTADA A3-I-02** |  | 2023-07-12 | 2023-08-05 |  |  |  |  |
| A1530 |  | EXCAVACIÓN EN TERRENO NATURAL CON EQUIPO | 12d | 2023-07-12 | 2023-07-26 | A1790 | 0d |  | Excavación |
| A1540 |  | EXCAVACIÓN DE UÑA CON EQUIPO | 11d | 2023-07-13 | 2023-07-26 | A1530 SS+1.25d, A1450 | 41.5d | 6.75d | Excavación |
| A1550 |  | PERFILADO Y COMPACTACIÓN EN ZONA DE CORTE | 9d | 2023-07-15 | 2023-07-26 | A1530 SS+3d | 0d |  |  |
| A1580 |  | GEOTEXTIL NO TEJIDO 400 G/M2, INC. COLOCACIÓN | 9d | 2023-07-17 | 2023-07-27 | A1550 SS+1.25d | 0d |  |  |
| A1590 |  | COLOCACION Y ACOMODO DE ROCA EN UÑA DE DIQUE | 8d | 2023-07-19 | 2023-07-28 | A1580 SS+1.25d | 0d |  | Roca |
| A1600 |  | COLOCACION Y ACOMODO DE ROCA EN TALUD DE DIQUE | 10d | 2023-07-20 | 2023-08-03 | A1590 SS+1.25d | 0d |  | Roca |
| A1610 |  | PREPARACIÓN DE FUNDACIÓN DE CUERPO DE DIQUE | 2d | 2023-07-21 | 2023-07-24 | A1530 SS+8d | 60.75d | 0d |  |
| A1560 |  | CONFORMACIÓN DE CUERPO DE DIQUE CON MATERIAL PROPIO | 2d | 2023-07-22 | 2023-07-25 | A1610 SS+1d | 60.75d | 13.75d | Relleno |
| A1570 |  | CONFORMACIÓN DE CORONA DE DIQUE CON MATERIAL PROPIO | 5d | 2023-07-31 | 2023-08-05 | A1600 FF+2d, A1480 | 13.5d | 0d | Relleno |
|  | 5 | **DIQUE DE TIERRA COMPACTADA A3-I-03** |  | 2023-08-04 | 2023-10-30 |  |  |  |  |
|  | 1 | **TRAMO 1** |  | 2023-08-04 | 2023-08-26 |  |  |  |  |
| A1620 |  | EXCAVACIÓN EN TERRENO NATURAL CON EQUIPO | 6d | 2023-08-04 | 2023-08-11 | A2630 | 0d |  | Excavación |
| A1630 |  | EXCAVACIÓN DE UÑA CON EQUIPO | 9d | 2023-08-05 | 2023-08-16 | A1620 SS+1.25d, A1540 | 34.75d | 9d | Excavación |
| A1640 |  | PERFILADO Y COMPACTACIÓN EN ZONA DE CORTE | 10d | 2023-08-05 | 2023-08-17 | A1620 SS+1.25d | 0d |  |  |
| A1670 |  | GEOTEXTIL NO TEJIDO 400 G/M2, INC. COLOCACIÓN | 10d | 2023-08-07 | 2023-08-18 | A1640 SS+1.25d | 0d |  |  |
| A1680 |  | COLOCACION Y ACOMODO DE ROCA EN UÑA DE DIQUE | 13d | 2023-08-09 | 2023-08-24 | A1670 SS+1.25d | 0d |  | Roca |
| A1690 |  | COLOCACION Y ACOMODO DE ROCA EN TALUD DE DIQUE | 12d | 2023-08-10 | 2023-08-24 | A1680 SS+1.25d | 0d |  | Roca |
| A1700 |  | PREPARACIÓN DE FUNDACIÓN DE CUERPO DE DIQUE | 4d | 2023-08-11 | 2023-08-16 | A1620 | 47d | 0d |  |
| A1650 |  | CONFORMACIÓN DE CUERPO DE DIQUE CON MATERIAL PROPIO | 4d | 2023-08-12 | 2023-08-17 | A1700 SS+1d, A1560 | 47d | 14d | Relleno |
| A1660 |  | CONFORMACIÓN DE CORONA DE DIQUE CON MATERIAL PROPIO | 5d | 2023-08-21 | 2023-08-26 | A1690 FF+2d, A1570 | 42d | 13d | Relleno |
|  | 2 | **TRAMO 2** |  | 2023-08-25 | 2023-09-18 |  |  |  |  |
| A2270 |  | EXCAVACIÓN EN TERRENO NATURAL CON EQUIPO | 6d | 2023-08-25 | 2023-09-02 | A2650 | 0d |  | Excavación |
| A2280 |  | EXCAVACIÓN DE UÑA CON EQUIPO | 9d | 2023-08-26 | 2023-09-07 | A2270 SS+1.25d, A1630 | 25.75d | 9d | Excavación |
| A2290 |  | PERFILADO Y COMPACTACIÓN EN ZONA DE CORTE | 10d | 2023-08-26 | 2023-09-08 | A2270 SS+1.25d | 0d |  |  |
| A2320 |  | GEOTEXTIL NO TEJIDO 400 G/M2, INC. COLOCACIÓN | 10d | 2023-08-28 | 2023-09-09 | A2290 SS+1.25d | 0d |  |  |
| A2330 |  | COLOCACION Y ACOMODO DE ROCA EN UÑA DE DIQUE | 13d | 2023-08-31 | 2023-09-15 | A2320 SS+1.25d | 0d |  | Roca |
| A2340 |  | COLOCACION Y ACOMODO DE ROCA EN TALUD DE DIQUE | 12d | 2023-09-01 | 2023-09-15 | A2330 SS+1.25d | 0d |  | Roca |
| A2350 |  | PREPARACIÓN DE FUNDACIÓN DE CUERPO DE DIQUE | 4d | 2023-09-02 | 2023-09-07 | A2270 | 33d | 0d |  |
| A2300 |  | CONFORMACIÓN DE CUERPO DE DIQUE CON MATERIAL PROPIO | 4d | 2023-09-04 | 2023-09-08 | A2350 SS+1d, A1650 | 33d | 14d | Relleno |
| A2310 |  | CONFORMACIÓN DE CORONA DE DIQUE CON MATERIAL PROPIO | 5d | 2023-09-12 | 2023-09-18 | A2340 FF+2d, A1660 | 29d | 13d | Relleno |

| ID | WBS | Activity | Duration | Start | Finish | Predecessors | Total float | Free float | Filtro |
| --- | --- | --- | --- | --- | --- | --- | --- | --- | --- |
|  | 3 | **TRAMO 3** |  | 2023-09-16 | 2023-10-09 |  |  |  |  |
| A2360 |  | EXCAVACIÓN EN TERRENO NATURAL CON EQUIPO | 6d | 2023-09-16 | 2023-09-23 | A2670 | 0d |  | Excavación |
| A2370 |  | EXCAVACIÓN DE UÑA CON EQUIPO | 9d | 2023-09-18 | 2023-09-28 | A2360 SS+1.25d, A2280 | 16.75d | 9d | Excavación |
| A2380 |  | PERFILADO Y COMPACTACIÓN EN ZONA DE CORTE | 10d | 2023-09-18 | 2023-09-29 | A2360 SS+1.25d | 0d |  |  |
| A2410 |  | GEOTEXTIL NO TEJIDO 400 G/M2, INC. COLOCACIÓN | 10d | 2023-09-19 | 2023-09-30 | A2380 SS+1.25d | 0d |  |  |
| A2420 |  | COLOCACION Y ACOMODO DE ROCA EN UÑA DE DIQUE | 13d | 2023-09-21 | 2023-10-06 | A2410 SS+1.25d | 0d |  | Roca |
| A2430 |  | COLOCACION Y ACOMODO DE ROCA EN TALUD DE DIQUE | 12d | 2023-09-22 | 2023-10-06 | A2420 SS+1.25d | 0d |  | Roca |
| A2440 |  | PREPARACIÓN DE FUNDACIÓN DE CUERPO DE DIQUE | 4d | 2023-09-23 | 2023-09-28 | A2360 | 19d | 0d |  |
| A2390 |  | CONFORMACIÓN DE CUERPO DE DIQUE CON MATERIAL PROPIO | 4d | 2023-09-25 | 2023-09-29 | A2440 SS+1d, A2300 | 19d | 14d | Relleno |
| A2400 |  | CONFORMACIÓN DE CORONA DE DIQUE CON MATERIAL PROPIO | 5d | 2023-10-03 | 2023-10-09 | A2430 FF+2d, A2310 | 16d | 13d | Relleno |
|  | 4 | **TRAMO 4** |  | 2023-10-07 | 2023-10-30 |  |  |  |  |
| A2450 |  | EXCAVACIÓN EN TERRENO NATURAL CON EQUIPO | 6d | 2023-10-07 | 2023-10-14 | A2690 | 0d |  | Excavación |
| A2460 |  | EXCAVACIÓN DE UÑA CON EQUIPO | 9d | 2023-10-09 | 2023-10-19 | A2450 SS+1.25d, A2370 | 7.75d | 0d | Excavación |
| A2470 |  | PERFILADO Y COMPACTACIÓN EN ZONA DE CORTE | 10d | 2023-10-09 | 2023-10-20 | A2450 SS+1.25d | 0d |  |  |
| A2500 |  | GEOTEXTIL NO TEJIDO 400 G/M2, INC. COLOCACIÓN | 10d | 2023-10-10 | 2023-10-21 | A2470 SS+1.25d | 0d |  |  |
| A2510 |  | COLOCACION Y ACOMODO DE ROCA EN UÑA DE DIQUE | 13d | 2023-10-12 | 2023-10-27 | A2500 SS+1.25d | 0d |  | Roca |
| A2520 |  | COLOCACION Y ACOMODO DE ROCA EN TALUD DE DIQUE | 12d | 2023-10-13 | 2023-10-27 | A2510 SS+1.25d | 0d |  | Roca |
| A2530 |  | PREPARACIÓN DE FUNDACIÓN DE CUERPO DE DIQUE | 4d | 2023-10-14 | 2023-10-19 | A2450 | 5d | 0d |  |
| A2480 |  | CONFORMACIÓN DE CUERPO DE DIQUE CON MATERIAL PROPIO | 4d | 2023-10-16 | 2023-10-20 | A2530 SS+1d, A2390 | 5d | 3.25d | Relleno |
| A2490 |  | CONFORMACIÓN DE CORONA DE DIQUE CON MATERIAL PROPIO | 5d | 2023-10-24 | 2023-10-30 | A2520 FF+2d, A2400 | 3d |  | Relleno |
|  | 6 | **RAMPAS** |  | 2023-10-03 | 2023-10-24 |  |  |  |  |
|  | 1 | **A3-RA-D-01** |  | 2023-10-03 | 2023-10-07 |  |  |  |  |
| A1710 |  | EXCAVACIÓN EN TERRENO NATURAL CON EQUIPO | 2d | 2023-10-03 | 2023-10-05 | A2190 | 19.5d | 0d | Excavación |
| A1720 |  | CONFORMACIÓN DE CUERPO DE RAMPA CON MATERIAL PROPIO | 2d | 2023-10-05 | 2023-10-07 | A1710 | 19.5d | 0d | Relleno |
| A1730 |  | CONFORMACIÓN DE CORONACIÓN DE RAMPA | 2d | 2023-10-05 | 2023-10-07 | A1720 SS | 19.5d | 11.75d | Relleno |

| ID | WBS | Activity | Duration | Start | Finish | Predecessors | Total float | Free float | Filtro |
| --- | --- | --- | --- | --- | --- | --- | --- | --- | --- |
|  | 2 | **A3-RA-I-01** |  | 2023-10-19 | 2023-10-24 |  |  |  |  |
| A1740 |  | EXCAVACIÓN EN TERRENO NATURAL CON EQUIPO | 2d | 2023-10-19 | 2023-10-21 | A2460 | 7.75d | 0d | Excavación |
| A1750 |  | CONFORMACIÓN DE CUERPO DE RAMPA CON MATERIAL PROPIO | 2d | 2023-10-21 | 2023-10-24 | A1740 | 7.75d | 0d | Relleno |
| A1760 |  | CONFORMACIÓN DE CORONACIÓN DE RAMPA | 2d | 2023-10-21 | 2023-10-24 | A1750 SS, A1730 | 7.75d |  | Relleno |
|  | 2 | **OBRAS DE ARTE** |  | 2023-05-15 | 2023-10-31 |  |  |  |  |
|  | 1 | **CAPTACIÓN A3-CP-23-95** |  | 2023-05-27 | 2023-09-24 |  |  |  |  |
|  | 1 | **MOVIMIENTO DE TIERRAS** |  | 2023-05-27 | 2023-07-17 |  |  |  |  |
| A2770 |  | EXCAVACIÓN ESTRUCTURAL PARA OBRAS DE ARTE | 5d | 2023-05-27 | 2023-06-02 | A3390 | 33.25d | 0d |  |
| A2780 |  | RELLENO ESTRUCTURAL PARA OBRAS DE ARTE, CON MATERIAL PROPIO | 4d | 2023-07-12 | 2023-07-17 | A2800 FS+12d | 76.75d | 0d |  |
|  | 2 | **OBRAS DE CONCRETO** |  | 2023-06-02 | 2023-06-27 |  |  |  |  |
| A2790 |  | CONCRETO f'c=100 kg/cm2 | 2d | 2023-06-02 | 2023-06-05 | A2770 | 44.25d | 0d |  |
| A2810 |  | CONCRETO CICLÓPEO f'c=280 kg/cm2 + 30% P.G. | 2d | 2023-06-05 | 2023-06-07 | A2790 | 44.25d | 0d |  |
| A2830 |  | ACERO DE REFUERZO fy=4200 kg/cm2 | 11d | 2023-06-07 | 2023-06-20 | A2810 | 44.25d | 0d |  |
| A2820 |  | ENCOFRADO Y DESENCOFRADO RECTO | 8d | 2023-06-12 | 2023-06-21 | A2830 FF+1d | 45.75d | 0d |  |
| A2800 |  | CONCRETO f'c=280 kg/cm2 | 10d | 2023-06-15 | 2023-06-27 | A2820 SS+3d | 46.75d | 0d |  |
|  | 3 | **ESTRUCTURAS METALICAS** |  | 2023-07-12 | 2023-07-24 |  |  |  |  |
| A2840 |  | COMPUERTA METALICA PLANA DESLIZANTE DE 1.0x1.0m | 2d | 2023-07-12 | 2023-07-14 | A2800 FS+12d | 83.75d | 0d |  |
| A2850 |  | REJILLA DE 1.00x1.00m CON VARILLA DE 1/2" CADA 6,25cm | 2d | 2023-07-14 | 2023-07-17 | A2840 | 83.75d | 0d |  |
| A2860 |  | BARANDA DE FIERRO GALVANIZADO 1 1/2" | 2d | 2023-07-17 | 2023-07-19 | A2850 | 83.75d | 0d |  |
| A2870 |  | ESCALERA TIPO GATO | 2d | 2023-07-19 | 2023-07-21 | A2860 | 83.75d | 0d |  |
| A2880 |  | TAPA METALICA CIRCULAR DN600 MM | 2d | 2023-07-21 | 2023-07-24 | A2870 | 83.75d |  |  |
|  | 4 | **TUBERIAS** |  | 2023-06-02 | 2023-07-31 |  |  |  |  |
| A2890 |  | EXCAVACIÓN ESTRUCTURAL PARA OBRAS DE ARTE (Buzones) | 2d | 2023-06-02 | 2023-06-05 | A2770 | 33.25d | 0d |  |
| A2900 |  | EXCAVACIÓN DE ZANJA | 21d | 2023-06-05 | 2023-06-30 | A2890 | 33.25d | 0d |  |
| A2920 |  | CAMA DE ARENA | 21d | 2023-06-08 | 2023-07-04 | A2900 SS+3d | 79.75d | 0d |  |
| A2940 |  | CONCRETO f'c=100 kg/cm2 (Buzones) | 2d | 2023-06-08 | 2023-06-10 | A2900 SS+3d, A2790 | 52.25d | 8d |  |
| A2990 |  | SUMINISTRO E INSTALACIÓN DE TUBERÍA GRP DN600 mm SN2500 | 21d | 2023-06-09 | 2023-07-05 | A2920 SS+1d | 79.75d | 0d |  |
| A2980 |  | ACERO DE REFUERZO fy=4200 kg/cm2 (Buzones) | 2.5d | 2023-06-20 | 2023-06-23 | A2940, A2830 | 44.25d | 0d |  |
| A2960 |  | ENCOFRADO Y DESENCOFRADO RECTO | 4d | 2023-06-23 | 2023-06-28 | A2820, A2980 | 44.25d | 0d |  |
| A2970 |  | ENCOFRADO Y DESENCOFRADO CURVO | 4d | 2023-06-23 | 2023-06-28 | A2960 SS | 44.25d | 0d |  |
| A2950 |  | CONCRETO f'c=280 kg/cm2 (Buzones) | 2d | 2023-06-28 | 2023-07-01 | A2970, A2800 | 46.25d | 1.5d |  |
| A2930 |  | RELLENO COMÚN PARA ZANJAS | 20d | 2023-07-05 | 2023-07-31 | A2990 | 79.75d |  |  |
| A2910 |  | RELLENO ESTRUCTURAL PARA OBRAS DE ARTE CON MATERIAL PROPIO (Buzones) | 2d | 2023-07-17 | 2023-07-19 | A2950 FS+12d, A2780 | 76.75d | 0d |  |

| ID | WBS | Activity | Duration | Start | Finish | Predecessors | Total float | Free float |
| --- | --- | --- | --- | --- | --- | --- | --- | --- |
|  | 5 | **CANAL** |  | 2023-06-30 | 2023-09-06 |  |  |  |
| A3000 |  | EXCAVACIÓN ESTRUCTURAL PARA OBRAS DE ARTE | 5d | 2023-06-30 | 2023-07-06 | A2900 | 33.25d | 0d |
| A3020 |  | COLOCACIÓN DE CONCRETO f'c=100 kg/cm2 | 2.5d | 2023-07-06 | 2023-07-09 | A2940, A3000 | 33.25d | 0d |
| A3050 |  | ACERO DE REFUERZO fy=4200 kg/cm2 | 22d | 2023-07-10 | 2023-08-06 | A2980, A3020 | 33.25d | 0d |
| A3040 |  | ENCOFRADO Y DESENCOFRADO RECTO | 43d | 2023-07-12 | 2023-09-03 | A2970, A3050 SS+2d | 33.25d | 0d |
| A3030 |  | COLOCACIÓN DE CONCRETO f'c=280 kg/cm2 | 43d | 2023-07-14 | 2023-09-06 | A2950 SS, A3040 SS+2d | 33.25d | 0d |
| A3060 |  | JUNTA WATER STOP SIN BULBO 150 mm | 43d | 2023-07-14 | 2023-09-06 | A3030 SS | 47.25d | 2d |
| A3010 |  | RELLENO ESTRUCTURAL PARA CANALES, CON MATERIAL PROPIO | 9d | 2023-07-19 | 2023-08-01 | A2910 | 76.75d | 43.5d |
|  | 6 | **OBRAS DE DESCARGA** |  | 2023-07-06 | 2023-09-24 |  |  |  |
| A3070 |  | EXCAVACIÓN ESTRUCTURAL PARA OBRAS DE ARTE | 2d | 2023-07-06 | 2023-07-08 | A3000 | 74.75d | 0.5d |
| A3090 |  | CONCRETO f'c=100 kg/cm2 | 2d | 2023-07-10 | 2023-07-12 | A3070, A3020 | 74.25d | 20d |
| A3120 |  | ACERO DE REFUERZO fy=4200 kg/cm2 | 2d | 2023-08-07 | 2023-08-09 | A3090, A3050 | 54.25d | 21d |
| A3110 |  | ENCOFRADO Y DESENCOFRADO RECTO | 2d | 2023-09-04 | 2023-09-06 | A3120, A3040 | 33.25d | 0d |
| A3100 |  | CONCRETO f'c=280 kg/cm2 | 2d | 2023-09-06 | 2023-09-08 | A3110, A3030 | 33.25d | 0d |
| A3130 |  | JUNTA WATER STOP SIN BULBO 150 mm | 2d | 2023-09-08 | 2023-09-10 | A3100, A3060 | 45.25d |  |
| A3080 |  | RELLENO ESTRUCTURAL PARA OBRAS DE ARTE CON MATERIAL PROPIO | 2d | 2023-09-22 | 2023-09-24 | A3100 FS+12d, A3010 | 33.25d |  |
| A3140 |  | COMPUERTA METALICA PLANA DESLIZANTE | 2d | 2023-09-22 | 2023-09-24 | A3100 FS+12d | 33.25d |  |
|  | 2 | **CAPTACIÓN A3-CP-21-05** |  | 2023-05-18 | 2023-08-15 |  |  |  |
|  | 1 | **MOVIMIENTO DE TIERRAS** |  | 2023-05-18 | 2023-07-08 |  |  |  |
| A3150 |  | EXCAVACIÓN ESTRUCTURAL PARA OBRAS DE ARTE | 2.5d | 2023-05-18 | 2023-05-20 | A1070 SS+6d | 33.25d | 0d |
| A3160 |  | RELLENO ESTRUCTURAL PARA OBRAS DE ARTE, CON MATERIAL PROPIO | 4d | 2023-07-04 | 2023-07-08 | A3180 FS+12d | 96.75d |  |
|  | 2 | **OBRAS DE CONCRETO** |  | 2023-05-20 | 2023-06-19 |  |  |  |
| A3170 |  | CONCRETO f'c=100 kg/cm2 | 2d | 2023-05-20 | 2023-05-23 | A3150 | 66.75d | 0d |
| A3190 |  | CONCRETO CICLÓPEO f'c=280 kg/cm2 + 30% P.G. | 2d | 2023-05-23 | 2023-05-25 | A3170 | 66.75d | 0d |
| A3210 |  | ACERO DE REFUERZO fy=4200 kg/cm2 | 17d | 2023-05-25 | 2023-06-14 | A3190 | 66.75d | 0d |
| A3200 |  | ENCOFRADO Y DESENCOFRADO RECTO | 12d | 2023-06-01 | 2023-06-15 | A3210 SS+6d | 68.75d | 0d |
| A3180 |  | CONCRETO f'c=280 kg/cm2 | 9d | 2023-06-08 | 2023-06-19 | A3200 SS+6d | 89.75d | 0d |

| ID | WBS | Activity | Duration | Start | Finish | Predecessors | Total float | Free float |
| --- | --- | --- | --- | --- | --- | --- | --- | --- |
|  | 3 | **ESTRUCTURAS METALICAS** |  | 2023-07-04 | 2023-07-15 |  |  |  |
| A3220 |  | COMPUERTA METALICA PLANA DESLIZANTE DE 1.0x1.0m | 2d | 2023-07-04 | 2023-07-06 | A3180 FS+12d | 90.75d | 0d |
| A3230 |  | REJILLA DE 1.00x1.00m CON VARILLA DE 1/2 CADA 6,25cm | 2d | 2023-07-06 | 2023-07-08 | A3220 | 90.75d | 0d |
| A3240 |  | BARANDA DE FIERRO GALVANIZADO 1 1/2" | 2d | 2023-07-08 | 2023-07-11 | A3230 | 90.75d | 0d |
| A3250 |  | ESCALERA TIPO GATO | 2d | 2023-07-11 | 2023-07-13 | A3240 | 90.75d | 0d |
| A3260 |  | TAPA METALICA CIRCULAR DN600 MM | 2d | 2023-07-13 | 2023-07-15 | A3250 | 90.75d |  |
|  | 4 | **TUBERIA** |  | 2023-05-20 | 2023-07-08 |  |  |  |
| A3270 |  | EXCAVACIÓN ESTRUCTURAL PARA OBRAS DE ARTE (Buzones) | 2d | 2023-05-20 | 2023-05-23 | A3150 | 33.25d | 0d |
| A3280 |  | EXCAVACIÓN DE ZANJA | 2d | 2023-05-23 | 2023-05-25 | A3270 | 122.75d | 0d |
| A3330 |  | CONCRETO f'c=100 kg/cm2 (Buzones) | 2d | 2023-05-23 | 2023-05-25 | A3270, A3170 | 83.75d | 2d |
| A3300 |  | CAMA DE ARENA | 2d | 2023-05-25 | 2023-05-27 | A3280 | 122.75d | 0d |
| A3380 |  | SUMINISTRO E INSTALACIÓN DE TUBERÍA GRP DN600 mm SN2500 | 2d | 2023-05-27 | 2023-05-30 | A3300 | 122.75d | 0d |
| A3310 |  | RELLENO SELECCIONADO PARA ZANJAS CON MATERIAL PROPIO | 2d | 2023-05-30 | 2023-06-01 | A3320 SS | 122.75d | 56d |
| A3320 |  | RELLENO COMÚN PARA ZANJAS | 2d | 2023-05-30 | 2023-06-01 | A3380 | 122.75d | 0d |
| A3370 |  | ACERO DE REFUERZO fy=4200 kg/cm2 | 2d | 2023-06-14 | 2023-06-16 | A3330, A3210 | 66.75d | 0d |
| A3350 |  | ENCOFRADO Y DESENCOFRADO RECTO | 2d | 2023-06-16 | 2023-06-19 | A3370, A3200 | 67.75d | 0d |
| A3360 |  | ENCOFRADO Y DESENCOFRADO CURVO | 2d | 2023-06-16 | 2023-06-19 | A3350 SS | 67.75d | 0d |
| A3340 |  | CONCRETO f'c=280 kg/cm2 (Buzones) | 2d | 2023-06-19 | 2023-06-21 | A3360, A3180 | 89.75d | 0d |
| A3290 |  | RELLENO ESTRUCTURAL PARA OBRAS DE ARTE CON MATERIAL PROPIO | 2d | 2023-07-06 | 2023-07-08 | A3340 FS+12d | 91.75d | 25d |
|  | 5 | **CANALES** |  | 2023-05-23 | 2023-08-15 |  |  |  |
| A3390 |  | EXCAVACIÓN ESTRUCTURAL PARA OBRAS DE ARTE | 4d | 2023-05-23 | 2023-05-27 | A3270, A3270 FF | 33.25d | 0d |
| A3410 |  | COLOCACIÓN DE CONCRETO f'c=100 kg/cm2 | 2d | 2023-05-27 | 2023-05-30 | A3390, A3330 | 81.75d | 15d |
| A3440 |  | ACERO DE REFUERZO fy=4200 kg/cm2 | 10d | 2023-06-16 | 2023-06-28 | A3410, A3370 | 66.75d | 0d |
| A3430 |  | ENCOFRADO Y DESENCOFRADO | 24d | 2023-06-20 | 2023-07-19 | A3440 SS+3d, A3360 | 66.75d | 0d |
| A3420 |  | COLOCACIÓN DE CONCRETO f'c=280 kg/cm2 | 4d | 2023-07-19 | 2023-07-24 | A3430, A3340 | 66.75d | 0d |
| A3450 |  | JUNTA WATER STOP SIN BULBO 150 mm | 2d | 2023-07-19 | 2023-07-21 | A3420 SS | 85.75d |  |
| A3400 |  | RELLENO ESTRUCTURAL PARA CANALES, CON MATERIAL PROPIO | 5d | 2023-08-09 | 2023-08-15 | A3420 FS+12d, A3290, A3310 | 66.75d |  |

| ID | WBS | Activity | Duration | Start | Finish | Predecessors | Total float | Free float |
| --- | --- | --- | --- | --- | --- | --- | --- | --- |
|  | 3 | **RETORNO A3-OA-RE-D-21-55** |  | 2023-05-15 | 2023-07-07 |  |  |  |
|  | 1 | **MOVIMIENTO DE TIERRAS** |  | 2023-05-15 | 2023-07-05 |  |  |  |
| A3460 |  | EXCAVACIÓN ESTRUCTURAL PARA OBRAS DE ARTE | 2d | 2023-05-15 | 2023-05-17 | A1070 SS+3d | 97.75d | 0d |
| A3470 |  | RELLENO ESTRUCTURAL PARA OBRAS DE ARTE, CON MATERIAL PROPIO | 2d | 2023-07-03 | 2023-07-05 | A3490 FS+12d | 100.25d |  |
|  | 2 | **OBRAS DE CONCRETO** |  | 2023-05-17 | 2023-06-17 |  |  |  |
| A3480 |  | CONCRETO f'c=100 kg/cm2 | 2d | 2023-05-17 | 2023-05-19 | A3460 | 97.75d | 0d |
| A3500 |  | CONCRETO CICLÓPEO f'c=280 kg/cm2 + 30% P.G. | 4d | 2023-05-19 | 2023-05-24 | A3480 | 97.75d | 0d |
| A3520 |  | ACERO DE REFUERZO fy=4200 kg/cm2 | 20d | 2023-05-19 | 2023-06-11 | A3500 SS | 97.75d | 0d |
| A3510 |  | ENCOFRADO Y DESENCOFRADO | 15d | 2023-05-26 | 2023-06-13 | A3520 SS+6d | 97.75d | 0d |
| A3490 |  | CONCRETO f'c=280 kg/cm2 | 4d | 2023-06-13 | 2023-06-17 | A3510 | 97.75d | 0d |
| A3530 |  | JUNTA WATER STOP SIN BULBO 150 mm | 4d | 2023-06-13 | 2023-06-17 | A3490 SS | 114.25d |  |
|  | 3 | **ESTRUCTURAS METALICAS** |  | 2023-07-03 | 2023-07-07 |  |  |  |
| A3540 |  | COMPUERTA METALICA PLANA DESLIZANTE DE 1.0x1.6 m | 2.5d | 2023-07-03 | 2023-07-05 | A3490 FS+12d | 97.75d | 0d |
| A3550 |  | BARANDA DE FIERRO GALVANIZADO 1 1/2" | 2d | 2023-07-05 | 2023-07-07 | A3540 | 97.75d |  |
|  | 4 | **REPOSICIÓN DE CANALES** |  | 2023-06-01 | 2023-10-31 |  |  |  |
|  | 1 | **REPOSICIÓN DE CANAL 1** |  | 2023-07-26 | 2023-10-31 |  |  |  |
|  | 1 | **MOVIMIENTO DE TIERRAS** |  | 2023-07-26 | 2023-10-31 |  |  |  |
| A3560 |  | DEMOLICIÓN DE ESTRUCTURAS EXISTENTES | 13d | 2023-07-26 | 2023-08-12 | A1530 | 68.75d |  |
| A3570 |  | EXCAVACIÓN EN TERRENO NATURAL CON EQUIPO | 29d | 2023-08-03 | 2023-09-07 | A1600 | 2d | 0d |
| A3580 |  | RELLENO ESTRUCTURAL PARA OBRAS DE ARTE CON MATERIAL PROPIO | 32d | 2023-09-23 | 2023-10-31 | A3620 SS+16d | 2d |  |
|  | 2 | **OBRAS DE CONCRETO** |  | 2023-08-10 | 2023-10-28 |  |  |  |
| A3610 |  | CONCRETO f'c=100 kg/cm2 | 29d | 2023-08-10 | 2023-09-14 | A3570 SS+6d | 2d | 0d |
| A3600 |  | ACERO DE REFUERZO fy=4200 kg/cm2 | 58d | 2023-08-14 | 2023-10-21 | A3610 SS+3d | 2d | 0d |
| A3590 |  | ENCOFRADO Y DESENCOFRADO RECTO | 52d | 2023-08-21 | 2023-10-21 | A3600 SS+6d | 2d | 0d |
| A3620 |  | CONCRETO f'c=280 kg/cm2 | 44d | 2023-09-05 | 2023-10-26 | A3590 SS+12d | 2d | 0d |
| A3630 |  | JUNTA WATER STOP 6" | 44d | 2023-09-05 | 2023-10-26 | A3620 SS | 6d |  |
| A3640 |  | MAMPOSTERIA DE PIEDRA, e=20cm, ACABADO CARA VISTA | 2d | 2023-10-26 | 2023-10-28 | A3620 | 4d |  |

| ID | WBS | Activity | Duration | Start | Finish | Predecessors | Total float | Free float |
| --- | --- | --- | --- | --- | --- | --- | --- | --- |
|  | 2 | **REPOSICIÓN DE CANAL 3** |  | 2023-06-01 | 2023-07-27 |  |  |  |
|  | 1 | **MOVIMIENTO DE TIERRAS** |  | 2023-06-01 | 2023-07-27 |  |  |  |
| A3650 |  | DEMOLICIÓN DE ESTRUCTURAS EXISTENTES | 8d | 2023-06-01 | 2023-06-10 | A1260 | 119.75d |  |
| A3660 |  | EXCAVACIÓN EN TERRENO NATURAL CON EQUIPO | 2.5d | 2023-06-21 | 2023-06-24 | A1330 | 80.75d | 0d |
| A3670 |  | RELLENO ESTRUCTURAL PARA OBRAS DE ARTE CON MATERIAL PROPIO | 2d | 2023-07-25 | 2023-07-27 | A3720 FS+6d | 80.75d |  |
|  | 2 | **OBRAS DE CONCRETO** |  | 2023-06-24 | 2023-07-20 |  |  |  |
| A3710 |  | CONCRETO f'c=100 kg/cm2 | 2.5d | 2023-06-24 | 2023-06-27 | A3660 | 80.75d | 0d |
| A3700 |  | MALLA ELECTROSOLDADA DE DN6mm EN CUADRICULA 15x15 cm | 12d | 2023-06-27 | 2023-07-12 | A3710 | 80.75d | 0d |
| A3680 |  | ENCOFRADO Y DESENCOFRADO PARA REVESTIMIENTO DE CANALES (CERCHAS) | 10d | 2023-07-01 | 2023-07-13 | A3700 SS+3d | 80.75d | 0d |
| A3690 |  | ENCOFRADO Y DESENCOFRADO RECTO | 10d | 2023-07-01 | 2023-07-13 | A3680 SS | 80.75d | 0d |
| A3730 |  | SELLO DE JUNTA CONSTRUCCIÓN CON MATERIAL ELASTOMÉRICO | 8d | 2023-07-01 | 2023-07-11 | A3680 SS | 94.75d |  |
| A3720 |  | CONCRETO f'c=280 kg/cm2 | 4d | 2023-07-13 | 2023-07-18 | A3690 | 80.75d | 0d |
| A3740 |  | MAMPOSTERIA DE PIEDRA, e=20cm, ACABADO CARA VISTA | 2d | 2023-07-18 | 2023-07-20 | A3720 | 86.75d |  |
|  | 5 | **REPOSICIÓN SIFON INOPERATIVO** |  | 2023-06-17 | 2023-07-26 |  |  |  |
| A3750 |  | DEMOLICIÓN DE ESTRUCTURAS EXISTENTES | 2d | 2023-06-17 | 2023-06-20 | A1230, A1880 | 81.75d | 0d |
| A3760 |  | EXCAVACIÓN ESTRUCTURAL PARA OBRAS DE ARTE | 8d | 2023-06-20 | 2023-06-30 | A3750 | 81.75d | 0d |
| A3770 |  | COLOCACIÓN CAMA DE ARENA | 2d | 2023-06-30 | 2023-07-03 | A3760 | 89.75d | 0d |
| A3810 |  | CONCRETO f'c=100 kg/cm2 | 2d | 2023-06-30 | 2023-07-03 | A3760 | 81.75d | 0d |
| A3800 |  | TUBERÍAS DE 14" HDPE SDR21 DN 355mm | 5d | 2023-07-03 | 2023-07-08 | A3770 | 89.75d | 0d |
| A3840 |  | ACERO DE REFUERZO fy=4200 kg/cm2 | 2d | 2023-07-03 | 2023-07-05 | A3810 | 81.75d | 0d |
| A3850 |  | CODOS HDPE DE 14" DN 355mm | 5d | 2023-07-03 | 2023-07-08 | A3800 SS | 96.75d |  |
| A3830 |  | ENCOFRADO Y DESENCOFRADO RECTO | 2d | 2023-07-05 | 2023-07-07 | A3840 | 81.75d | 0d |
| A3820 |  | CONCRETO f'c=280 kg/cm2 | 2d | 2023-07-07 | 2023-07-10 | A3830 | 81.75d | 0d |
| A3790 |  | RELLENO COMÚN | 7d | 2023-07-08 | 2023-07-17 | A3800 | 89.75d |  |
| A3780 |  | RELLENO ESTRUCTURAL PARA OBRAS DE ARTE CON MATERIAL PROPIO | 2d | 2023-07-24 | 2023-07-26 | A3820 FS+12d | 81.75d |  |

| ID | WBS | Activity | Duration | Start | Finish | Predecessors | Total float | Free float | Filtro |
| --- | --- | --- | --- | --- | --- | --- | --- | --- | --- |
|  | 3 | **ARQUITECTURA Y PAISAJISMO** |  | 2023-08-05 | 2023-10-17 |  |  |  |  |
|  | 1 | **OBRAS PRELIMINARES** |  | 2023-08-05 | 2023-10-17 |  |  |  |  |
| A3860 |  | MOVILIZACIÓN DE EQUIPOS Y HERRAMIENTAS (ARQUITECTURA Y PAISAJISMO) | 2d | 2023-08-05 | 2023-08-08 | A1570 | 13.5d | 0d |  |
| A3870 |  | TRAZO Y REPLANTEO PRELIMINAR | 2.5d | 2023-08-08 | 2023-08-10 | A3860 | 13.5d | 0d |  |
| A4020 |  | DEMOVILIZACIÓN DE EQUIPOS Y HERRAMIENTAS (ARQUITECTURA Y PAISAJISMO) | 2d | 2023-10-14 | 2023-10-17 | A4010, A3900 | 13.5d |  |  |
|  | 2 | **MOVIMIENTO DE TIERRAS** |  | 2023-08-10 | 2023-08-26 |  |  |  |  |
| A3880 |  | EXCAVACIÓN MANUAL PARA INSTALACIÓN DE BORDILLOS Y CIMENTACIONES | 2d | 2023-08-10 | 2023-08-12 | A3870 | 13.5d | 0d |  |
| A3900 |  | ELIMINACION DE MATERIAL EXCEDENTE (DME´S) | 14d | 2023-08-10 | 2023-08-26 | A3880 SS | 54.5d | 41d |  |
| A3890 |  | EXCAVACIÓN PARA MEJORAMIENTO DE SUELO CON TIERRA VEGETAL | 12d | 2023-08-12 | 2023-08-26 | A3880 | 13.5d | 0d |  |
|  | 3 | **PAVIMENTOS, RECUBRIMIENTOS Y BORDILLOS** |  | 2023-08-26 | 2023-09-07 |  |  |  |  |
| A3910 |  | PISO DE GRAVILLA | 2d | 2023-08-26 | 2023-08-29 | A3890 | 13.5d | 0d |  |
| A3920 |  | RECUBRIMIENTO DE PIEDRA DEL LUGAR e=0.05cm | 2.5d | 2023-08-29 | 2023-09-02 | A3910 | 13.5d | 0d |  |
| A3930 |  | BORDILLOS DE PIEDRA DEL LUGAR | 4d | 2023-09-02 | 2023-09-07 | A3920 | 13.5d | 0d |  |
|  | 4 | **MOBILIARIOS, BARANDAS Y ESCALERAS** |  | 2023-09-07 | 2023-10-12 |  |  |  |  |
| A3940 |  | ESCALERA DE CONCRETO SOBRE ENROCADO, CIMENTACION Y ANCLAJE | 8d | 2023-09-07 | 2023-09-16 | A3930 | 13.5d | 0d |  |
| A3950 |  | BARANDA DE MADERA EUCALIPTO CON SOGA, INCLUYE CIMENTACIÓN | 4d | 2023-09-16 | 2023-09-21 | A3940 | 13.5d | 0d |  |
| A3960 |  | TACHOS DE BASURA, INCLUYE CIMENTACIÓN | 2d | 2023-09-21 | 2023-09-23 | A3950 | 13.5d | 0d |  |
| A3970 |  | BANCAS DE CONCRETO, INCLUYE CIMENTACIÓN | 8d | 2023-09-23 | 2023-10-03 | A3960 | 13.5d | 0d |  |
| A3980 |  | POSTES DE ILUMINACIÓN, INCLUYE LUMINARIA Y CIMENTACIÓN | 4d | 2023-10-03 | 2023-10-07 | A3970 | 13.5d | 0d |  |
| A3990 |  | SEÑALETICA INFORMATIVA | 2d | 2023-10-07 | 2023-10-10 | A3980 | 13.5d | 0d |  |
| A4000 |  | BOLARDOS DE PIEDRA | 2.5d | 2023-10-10 | 2023-10-12 | A3990 | 13.5d | 0d |  |
|  | 5 | **INSTALACIÓN DE ALCORQUES** |  | 2023-10-12 | 2023-10-14 |  |  |  |  |
| A4010 |  | ALCORQUES DE PIEDRA DE CANTO RODADO PARA ARBOLES | 2d | 2023-10-12 | 2023-10-14 | A4000 | 13.5d | 0d |  |
|  | 4 | **PROGRAMA DE CIERRE DE OBRA** |  | 2023-05-17 | 2023-10-31 |  |  |  |  |
| A1770 |  | ACONDICIONAMIENTO DE DEPOSITOS DE MATERIALES EXCEDENTES (DME) | 133d | 2023-05-17 | 2023-10-24 | A1220 SS | 1.75d | 0d | Excavación |
| A1780 |  | RESTAURACIÓN DE ÁREAS DE INSTALACIONES PROVISIONALES | 6d | 2023-10-24 | 2023-10-31 | A2480, A1770 | 1.75d |  |  |
